# 2instturnaround

Schedule from MS Project, 2007-05-30 to 2007-06-05.
MBARI

## Calendars

- Standard: Mon-Fri 08:00-12:00, 13:00-17:00; Sat-Sun off.

## Schedule

| ID | WBS | Task | Duration | Start | Finish | Predecessors | Total slack | Free slack |
| --- | --- | --- | --- | --- | --- | --- | --- | --- |
| 1 | 1 | **2 Instrument turnaround** | 4.25d | 2007-05-30 08:00 | 2007-06-05 10:00 |  | 0d |  |
| 2 | 1.1 | Steam to pt 1 | 1h | 2007-05-30 08:00 | 2007-05-30 09:00 |  | 0d |  |
| 3 | 1.2 | Recover inst 1 | 2h | 2007-05-30 09:00 | 2007-05-30 11:00 | 2 | 0d |  |
| 4 | 1.3 | Steam to MBARI | 1h | 2007-05-30 11:00 | 2007-05-30 12:00 | 3 | 0d |  |
| 5 | 1.4 | Dock | 1h | 2007-05-30 13:00 | 2007-05-30 14:00 | 4 | 0d |  |
| 6 | 1.5 | Off Load Inst | 1h | 2007-05-30 14:00 | 2007-05-30 15:00 | 5 | 0d |  |
| 7 | 1.6 | Disassembly mooring | 30min | 2007-05-30 15:00 | 2007-05-30 15:30 | 6 | 0d |  |
| 8 | 1.7 | Uncan | 1h | 2007-05-30 15:30 | 2007-05-30 16:30 | 7 | 0d |  |
| 9 | 1.8 | Inspect | 15min | 2007-05-30 16:30 | 2007-05-30 16:45 | 8 | 0d |  |
| 10 | 1.9 | Clean | 15min | 2007-05-30 16:45 | 2007-05-30 17:00 | 9 | 0d |  |
| 11 | 1.10 | Vacuum Waste | 15min | 2007-05-31 08:00 | 2007-05-31 08:15 | 10 | 0d |  |
| 12 | 1.11 | Load new reagents | 30min | 2007-05-31 08:15 | 2007-05-31 08:45 | 11 | 0d |  |
| 13 | 1.12 | Load new pucks | 1h | 2007-05-31 08:45 | 2007-05-31 09:45 | 12 | 0d |  |
| 14 | 1.13 | Can | 15min | 2007-05-31 09:45 | 2007-05-31 10:00 | 13 | 0d |  |
| 15 | 1.14 | Assemble mooring | 30min | 2007-05-31 10:00 | 2007-05-31 10:30 | 14 | 0d |  |
| 16 | 1.15 | He Purge | 1h | 2007-05-31 10:30 | 2007-05-31 11:30 | 15 | 2.62d | 0d |
| 17 | 1.16 | Leak test | 30min | 2007-05-31 11:30 | 2007-05-31 12:00 | 16 | 2.62d | 0d |
| 18 | 1.17 | N2 purge | 1h | 2007-05-31 13:00 | 2007-05-31 14:00 | 17 | 2.62d |  |
| 19 | 1.18 | Run QC | 4h | 2007-05-31 10:30 | 2007-05-31 15:30 | 15 | 0d |  |
| 20 | 1.19 | Load inst (on boat) | 1h | 2007-05-31 15:30 | 2007-05-31 16:30 | 19 | 0d |  |
| 21 | 1.20 | Steam to Pt 1 | 1h | 2007-05-31 16:30 | 2007-06-01 08:30 | 20 | 0d |  |
| 22 | 1.21 | Deploy Inst 1 | 3h | 2007-06-01 08:30 | 2007-06-01 11:30 | 21 | 0d |  |
| 23 | 1.22 | Steam to Pt 2 | 1h | 2007-06-01 11:30 | 2007-06-01 13:30 | 22 | 0d |  |
| 24 | 1.23 | Recover Inst 2 | 2h | 2007-06-01 13:30 | 2007-06-01 15:30 | 23 | 0d |  |
| 25 | 1.24 | Steam to MBARI | 1h | 2007-06-01 15:30 | 2007-06-01 16:30 | 24 | 0d |  |
| 26 | 1.25 | Off Load Inst | 1h | 2007-06-01 16:30 | 2007-06-04 08:30 | 25 | 0d |  |
| 27 | 1.26 | Disassembly mooring | 30min | 2007-06-04 08:30 | 2007-06-04 09:00 | 26 | 0d |  |
| 28 | 1.27 | Uncan | 1h | 2007-06-04 09:00 | 2007-06-04 10:00 | 27 | 0d |  |
| 29 | 1.28 | Inspect | 15min | 2007-06-04 10:00 | 2007-06-04 10:15 | 28 | 0d |  |
| 30 | 1.29 | Clean | 15min | 2007-06-04 10:15 | 2007-06-04 10:30 | 29 | 0d |  |
| 31 | 1.30 | Vacuum Waste | 15min | 2007-06-04 10:30 | 2007-06-04 10:45 | 30 | 0d |  |
| 32 | 1.31 | Load new reagents | 30min | 2007-06-04 10:45 | 2007-06-04 11:15 | 31 | 0d |  |
| 33 | 1.32 | Load new pucks | 1h | 2007-06-04 11:15 | 2007-06-04 13:15 | 32 | 0d |  |
| 34 | 1.33 | Can | 15min | 2007-06-04 13:15 | 2007-06-04 13:30 | 33 | 0d |  |
| 35 | 1.34 | Assemble mooring | 30min | 2007-06-04 13:30 | 2007-06-04 14:00 | 34 | 0d |  |
| 36 | 1.35 | He Purge | 1h | 2007-06-04 14:00 | 2007-06-04 15:00 | 35 | 0.31d | 0d |
| 37 | 1.36 | Leak test | 30min | 2007-06-04 15:00 | 2007-06-04 15:30 | 36 | 0.31d | 0d |
| 38 | 1.37 | N2 purge | 1h | 2007-06-04 15:30 | 2007-06-04 16:30 | 37 | 0.31d |  |
| 39 | 1.38 | Run QC | 4h | 2007-06-04 14:00 | 2007-06-05 09:00 | 35 | 0d |  |
| 40 | 1.39 | Load inst (on boat) | 1h | 2007-06-05 09:00 | 2007-06-05 10:00 | 39 | 0d |  |
