# ESP_planning2007_v3

Schedule from MS Project, 2006-08-02 to 2008-08-13, A marks actual dates.
MBARI

## Calendars

- Standard: Mon-Fri 08:00-12:00, 13:00-17:00; Sat-Sun off.

## Resources

| Resource |
| --- |
| Brent |
| Cheri |
| Chris |
| Doug |
| Scott |
| Addie |
| Mike |
| Jose |
| Tech |
| 232 |
| 233 |
| 234 |

## Schedule

| ID | WBS | Task | Type | Duration | Start | Finish | Predecessors | Total slack | Free slack | Constraint | Work |
| --- | --- | --- | --- | --- | --- | --- | --- | --- | --- | --- | --- |
| 1 | 1 | **Deep ESP/NASA ASTEP** |  | 531d? | 2006-08-02 | 2008-08-13 |  | 0d |  |  | 40h |
| 2 | 1.1 | **Complete Control S/W** |  | 63d | 2006-08-02 | 2006-10-27 |  | 468d |  |  |  |
| 3 | 1.1.1 | Operational modes verified |  | 20d | 2006-08-02 | 2006-08-29 |  | 468d | 0d |  |  |
| 4 | 1.1.2 | S/W states implemented |  | 20d | 2006-08-30 | 2006-09-26 | 3 | 468d | 0d |  |  |
| 5 | 1.1.3 | DWSM Protocols |  | 5d | 2006-09-27 | 2006-10-03 | 4 | 468d | 0d |  |  |
| 6 | 1.1.4 | DWSM Software test plan |  | 1d | 2006-10-04 | 2006-10-04 | 5 | 468d | 0d |  |  |
| 7 | 1.1.5 | DWSM Software tests |  | 5d | 2006-10-05 | 2006-10-11 | 6 | 468d | 0d |  |  |
| 8 | 1.1.6 | Analyze at different pressures |  | 5d | 2006-10-12 | 2006-10-18 | 7 | 468d | 0d |  |  |
| 9 | 1.1.7 | Help with cold room tests |  | 2d | 2006-10-19 | 2006-10-20 | 8 | 468d | 0d |  |  |
| 10 | 1.1.8 | Analyze at different temperatures |  | 5d | 2006-10-23 | 2006-10-27 | 9 | 468d |  |  |  |
| 11 | 1.2 | **Core redesign** |  | 296d | 2006-08-07 | 2007-09-24 |  | 232d |  |  |  |
| 12 | 1.2.1 | Waste container & struts redesign |  | 5d | 2006-08-07 | 2006-08-11 |  | 503d | 0d | start no earlier than 2006-08-07 |  |
| 13 | 1.2.2 | Reagent Storage design |  | 10d | 2006-09-11 | 2006-09-22 |  | 460d | 0d | start no earlier than 2006-09-11 |  |
| 14 | 1.2.3 | Waste container fab |  | 20d | 2006-08-14 | 2006-09-08 | 12 | 503d |  |  |  |
| 15 | 1.2.4 | Reagent storage fab. |  | 10d | 2006-09-25 | 2006-10-06 | 13 | 460d | 168d |  |  |
| 16 | 1.2.5 | **Extend Carousel** |  | 83d | 2007-05-31 | 2007-09-24 | 15 | 232d |  |  |  |
| 17 | 1.2.5.1 | Redesign structs |  | 2d | 2007-05-31 | 2007-06-01 | 29 | 303d | 0d |  |  |
| 18 | 1.2.5.2 | Redesign Carousel |  | 10d | 2007-06-04 | 2007-06-15 | 17 | 303d |  |  |  |
| 19 | 1.2.5.3 | Fab. Carousel |  | 20d | 2007-08-23 | 2007-09-19 | 37 | 232d | 0d |  |  |
| 20 | 1.2.5.4 | Fab. Struts |  | 3d | 2007-09-20 | 2007-09-24 | 19 | 232d |  |  |  |
| 21 | 1.3 | **4k DWSM Design** |  | 153d | 2007-03-19 | 2007-10-17 |  | 0d |  | start no earlier than 2007-01-08 |  |
| 22 | 1.3.1 | Define Functional Requirements |  | 15d | 2007-03-19 | 2007-04-06 |  | 0d |  | start no earlier than 2007-03-19 |  |
| 23 | 1.3.2 | DWSM Process Design |  | 10d | 2007-04-09 | 2007-04-20 | 22 | 0d |  |  |  |
| 24 | 1.3.3 | Deployment concept design (elev/sled) |  | 10d | 2007-04-23 | 2007-05-04 | 23 | 0d |  |  |  |
| 25 | 1.3.4 | Archetecture design |  | 5d | 2007-05-07 | 2007-05-11 | 24 | 0d |  |  |  |
| 26 | 1.3.5 | Design trades for 4K housings |  | 5d | 2007-05-14 | 2007-05-18 | 25 | 0d |  | start no earlier than 2007-04-02 |  |
| 27 | 1.3.6 | Develop Test Plan |  | 3d | 2007-05-21 | 2007-05-23 | 26 | 0d |  |  |  |
| 28 | 1.3.7 | PDR Prep |  | 5d | 2007-05-24 | 2007-05-30 | 27 | 0d |  |  |  |
| 29 | 1.3.8 | PDR | milestone | 0d | 2007-05-30 | 2007-05-30 | 28 | 0d |  |  |  |
| 30 | 1.3.9 | PDR Sched | milestone | 0d | 2007-05-23 | 2007-05-23 |  | 321d |  | start no earlier than 2007-05-23 |  |
| 31 | 1.3.10 | Design deep housing |  | 15d | 2007-05-31 | 2007-06-20 | 29 | 0d |  |  |  |
| 32 | 1.3.11 | 4k Housing CDR | milestone | 0d | 2007-06-20 | 2007-06-20 | 31 | 0d |  |  |  |
| 33 | 1.3.12 | CDR Scheduled | milestone | 0d | 2007-06-06 | 2007-06-06 |  | 311d |  | start no earlier than 2007-06-06 |  |
| 34 | 1.3.13 | Sub-System redesign for 4K actuation |  | 40d | 2007-06-21 | 2007-08-15 | 32 | 0d |  |  |  |
| 35 | 1.3.14 | Universal power interface |  | 30d | 2007-06-21 | 2007-08-01 | 32 | 10d |  |  |  |
| 36 | 1.3.15 | CDR Preparation |  | 5d | 2007-08-16 | 2007-08-22 | 35, 34 | 0d |  |  |  |
| 37 | 1.3.16 | CDR | milestone | 0d | 2007-08-22 | 2007-08-22 | 36 | 0d |  |  |  |
| 38 | 1.3.17 | CDR Scheduled | milestone | 0d | 2007-08-22 | 2007-08-22 |  | 256d |  | start no earlier than 2007-08-22 |  |
| 39 | 1.3.18 | Modify DWSM SW |  | 40d | 2007-08-23 | 2007-10-17 | 37 | 215d |  |  |  |

| ID | WBS | Task | Type | Duration | Start | Finish | Predecessors | Total slack | Free slack | Constraint |
| --- | --- | --- | --- | --- | --- | --- | --- | --- | --- | --- |
| 40 | 1.4 | **4k Housing Fabrication** |  | 230d | 2007-06-21 | 2008-05-07 |  | 30d |  |  |
| 41 | 1.4.1 | 4k Housing Vendor RFQ |  | 10d | 2007-06-21 | 2007-07-04 | 32 | 30d | 0d |  |
| 42 | 1.4.2 | RFQ-Review | milestone | 0d | 2007-07-04 | 2007-07-04 | 41 | 30d | 0d |  |
| 43 | 1.4.3 | Proposal time |  | 30d | 2007-07-05 | 2007-08-15 | 42 | 30d | 0d |  |
| 44 | 1.4.4 | Vendor evaluations |  | 10d | 2007-08-16 | 2007-08-29 | 43 | 30d | 0d |  |
| 45 | 1.4.5 | Selection and order of 4k Housing(s) | milestone | 0d | 2007-08-29 | 2007-08-29 | 37, 44 | 30d | 0d |  |
| 46 | 1.4.6 | Lead time |  | 160d | 2007-08-30 | 2008-04-09 | 45 | 30d | 0d |  |
| 47 | 1.4.7 | Testing |  | 20d | 2008-04-10 | 2008-05-07 | 46 | 30d |  |  |
| 48 | 1.5 | **4k DWSM Fabrication** |  | 175d | 2007-08-23 | 2008-04-23 |  | 0d |  |  |
| 49 | 1.5.1 | Build Order lists/Quotes |  | 10d | 2007-08-23 | 2007-09-05 | 37 | 0d |  |  |
| 50 | 1.5.2 | Purchase COTS |  | 5d | 2007-09-06 | 2007-09-12 | 49 | 0d |  |  |
| 51 | 1.5.3 | Lead Time |  | 120d | 2007-09-13 | 2008-02-27 | 50 | 0d |  |  |
| 52 | 1.5.4 | Fabrication |  | 60d | 2007-09-13 | 2007-12-05 | 50 | 60d |  |  |
| 53 | 1.5.5 | Assembly |  | 40d | 2008-02-28 | 2008-04-23 | 52, 51 | 0d |  |  |
| 54 | 1.6 | **4k DWSM Testing** |  | 80d | 2008-04-24 | 2008-08-13 |  | 0d |  |  |
| 55 | 1.6.1 | SubSystem Test |  | 20d | 2008-04-24 | 2008-05-21 | 53 | 0d |  |  |
| 56 | 1.6.2 | IST |  | 20d | 2008-05-22 | 2008-06-18 | 55 | 0d |  |  |
| 57 | 1.6.3 | Cold Room Testing |  | 10d | 2008-06-19 | 2008-07-02 | 56, 47 | 0d |  |  |
| 58 | 1.6.4 | Pressure Testing |  | 10d | 2008-07-03 | 2008-07-16 | 57 | 0d |  |  |
| 59 | 1.6.5 | Dive Testing |  | 20d | 2008-07-17 | 2008-08-13 | 58 | 0d |  |  |
| 60 | 1.7 | **Sniffer Wand** |  | 10d | 2007-05-07 | 2007-05-18 |  | 323d |  |  |
| 61 | 1.7.1 | Mech Design |  | 2d | 2007-05-07 | 2007-05-08 |  | 323d | 0d | start no earlier than 2007-05-07 |
| 62 | 1.7.2 | Elect design |  | 1d | 2007-05-09 | 2007-05-09 | 61 | 323d | 0d |  |
| 63 | 1.7.3 | CDR |  | 1d | 2007-05-10 | 2007-05-10 | 62 | 323d | 0d |  |
| 64 | 1.7.4 | Fabrication |  | 5d | 2007-05-11 | 2007-05-17 | 63 | 323d | 0d |  |
| 65 | 1.7.5 | Testing |  | 1d | 2007-05-18 | 2007-05-18 | 64 | 323d |  |  |

| ID | WBS | Task | Type | Duration | Start | Finish | Predecessors | Total slack | Free slack | Constraint | Resources | Work |
| --- | --- | --- | --- | --- | --- | --- | --- | --- | --- | --- | --- | --- |
| 66 | 1.8 | **ISUS Integration** |  | 66d | 2007-03-26 | 2007-06-25 |  | 297d |  |  |  |  |
| 67 | 1.8.1 | System testing |  | 5d | 2007-03-26 | 2007-03-30 |  | 308d | 0d | start no earlier than 2007-03-26 |  |  |
| 68 | 1.8.2 | Deep Housing Fabrication |  | 15d | 2007-06-05 | 2007-06-25 | 84 | 297d |  |  |  |  |
| 69 | 1.8.3 | Mounting fabrication |  | 15d | 2007-04-02 | 2007-04-20 | 67 | 308d | 0d |  |  |  |
| 70 | 1.8.4 | Cable order |  | 30d | 2007-04-23 | 2007-06-01 | 69 | 308d | 0d |  |  |  |
| 71 | 1.8.5 | IST |  | 5d | 2007-06-04 | 2007-06-08 | 70 | 308d |  |  |  |  |
| 72 | 1.9 | **CTD Integration** |  | 35d | 2007-03-26 | 2007-05-11 |  | 328d |  |  |  |  |
| 73 | 1.9.1 | Cable order |  | 30d | 2007-03-26 | 2007-05-04 |  | 328d | 0d | start no earlier than 2007-03-26 |  |  |
| 74 | 1.9.2 | IST |  | 5d | 2007-05-07 | 2007-05-11 | 73 | 328d |  |  |  |  |
| 75 | 1.10 | **LLNL PCR Module** |  | 1d? | 2006-08-02 | 2006-08-02 |  | 530d |  |  |  |  |
| 76 | 1.10.1 | Prototype |  | 1d? | 2006-08-02 | 2006-08-02 |  | 530d |  |  |  |  |
| 77 | 1.10.2 | CDR |  | 1d? | 2006-08-02 | 2006-08-02 |  | 530d |  |  |  |  |
| 78 | 1.10.3 | Production |  | 1d? | 2006-08-02 | 2006-08-02 |  | 530d |  |  |  |  |
| 79 | 1.10.4 | Delivery |  | 1d? | 2006-08-02 | 2006-08-02 |  | 530d |  |  |  |  |
| 80 | 1.10.5 | Tech support |  | 1d? | 2006-08-02 | 2006-08-02 |  | 530d |  |  |  |  |
| 81 | 1.11 | **Deep E-SP Deployments** |  | 57d | 2007-05-21 | 2007-08-07 |  | 0d |  |  |  | 40h |
| 82 | 1.11.1 | 1k DWSM Testing |  | 4d | 2007-05-21 | 2007-05-24 |  | 32d | 0d | start no earlier than 2007-05-21 |  |  |
| 83 | 1.11.2 | 1k DWSM cleanout |  | 1d | 2007-05-25 | 2007-05-25 | 82 | 32d | 6d |  |  |  |
| 84 | 1.11.3 | 1k D-ESP Benthic CDR | milestone | 0d | 2007-06-05 | 2007-06-05 | 83 | 26d | 0d | start no earlier than 2007-06-05 |  |  |
| 85 | 1.11.4 | A1/1kDWSM integration |  | 3d | 2007-07-09 | 2007-07-11 | 84 | 2d | 0d | start no earlier than 2007-07-09 | Brent | 24h |
| 86 | 1.11.5 | ISUS/CTD/Sniffer Integration |  | 2d | 2007-07-12 | 2007-07-13 | 85 | 2d | 0d |  | Brent | 16h |
| 87 | 1.11.6 | Can |  | 1d | 2007-07-16 | 2007-07-16 | 86 | 2d | 0d |  |  |  |
| 88 | 1.11.7 | Sled |  | 1d | 2007-07-17 | 2007-07-17 | 87 | 2d | 0d |  |  |  |
| 89 | 1.11.8 | Test Tank |  | 2d | 2007-07-18 | 2007-07-19 | 88 | 2d | 0d |  |  |  |
| 90 | 1.11.9 | Uncan |  | 1d | 2007-07-20 | 2007-07-20 | 89 | 2d | 0d |  |  |  |
| 91 | 1.11.10 | Load pucks/Reagents |  | 1d | 2007-07-23 | 2007-07-23 | 90 | 2d | 0d |  |  |  |
| 92 | 1.11.11 | Can |  | 2d | 2007-07-24 | 2007-07-25 | 91 | 2d | 0d |  |  |  |
| 93 | 1.11.12 | Build sled |  | 3d | 2007-07-26 | 2007-07-30 | 92 | 2d | 0d |  |  |  |
| 94 | 1.11.13 | Run controls |  | 1d | 2007-07-31 | 2007-07-31 | 93 | 2d |  |  |  |  |
| 95 | 1.11.14 | MOB |  | 1d | 2007-08-03 | 2007-08-03 | 94 | 0d |  | start no earlier than 2007-08-03 |  |  |
| 96 | 1.11.15 | Dive Window |  | 2d | 2007-08-06 | 2007-08-07 | 95 | 0d |  | must start on 2007-08-06 |  |  |

| ID | WBS | Task | Type | Duration | Start | Finish | Predecessors | Complete | Remaining | Baseline start | Baseline finish | Baseline duration | Total slack | Free slack | Constraint | Work |
| --- | --- | --- | --- | --- | --- | --- | --- | --- | --- | --- | --- | --- | --- | --- | --- | --- |
| 98 | 2 | **NSF Tech Transfer** |  | 222d? | 2006-12-04 A | 2007-10-09 |  | 10% | 198.85d? |  |  |  | 221d |  |  | 464h |
| 99 | 2.1 | A1 Build Up |  | 65d | 2006-12-04 A | 2007-03-02 |  | 90% | 6.5d |  |  |  | 221d | 0d | start no earlier than 2006-12-04 |  |
| 100 | 2.2 | A1 Built | milestone | 0d | 2007-03-02 | 2007-03-02 | 99 |  |  |  |  |  | 221d | 0d |  |  |
| 101 | 2.3 | A1 Engr Test-Out |  | 60d | 2007-03-05 | 2007-05-25 | 100 |  |  |  |  |  | 261d | 0d |  |  |
| 102 | 2.4 | A1 Validation |  | 20d | 2007-05-28 | 2007-06-22 | 101 |  |  |  |  |  | 283d | 0d |  |  |
| 103 | 2.5 | Cold water test |  | 3d | 2007-06-25 | 2007-06-27 | 102 |  |  |  |  |  | 290d | 0d |  | 64h |
| 104 | 2.6 | Tank test |  | 5d | 2007-06-28 | 2007-07-04 | 103 |  |  |  |  |  | 290d |  |  | 64h |
| 105 | 2.7 | **+3 Build Up** |  | 100d | 2007-03-05 | 2007-07-20 | 100 |  |  |  |  |  | 221d | 0d |  |  |
| 106 | 2.7.1 | TT1 Build |  | 100d | 2007-03-05 | 2007-07-20 |  |  |  |  |  |  | 221d |  | start no earlier than 2007-01-01 |  |
| 107 | 2.7.2 | TT2 Build |  | 100d | 2007-03-05 | 2007-07-20 |  |  |  |  |  |  | 221d |  | start no earlier than 2007-01-01 |  |
| 108 | 2.7.3 | TT3 Build |  | 100d | 2007-03-05 | 2007-07-20 |  |  |  |  |  |  | 221d |  | start no earlier than 2007-01-01 |  |
| 109 | 2.8 | +3 Built | milestone | 0d | 2007-07-20 | 2007-07-20 | 105 |  |  |  |  |  | 221d | 0d | start no earlier than 2007-06-15 |  |
| 110 | 2.9 | +3 Engr Test-Out |  | 20d | 2007-07-23 | 2007-08-17 | 101, 109 |  |  |  |  |  | 221d | 0d |  |  |
| 111 | 2.10 | +3 Validation |  | 20d | 2007-08-20 | 2007-09-14 | 110 |  |  |  |  |  | 221d | 0d |  |  |
| 112 | 2.11 | Cold water test |  | 3d | 2007-09-17 | 2007-09-19 | 111 |  |  |  |  |  | 221d | 0d |  | 64h |
| 113 | 2.12 | Tank test |  | 5d | 2007-09-20 | 2007-09-26 | 112 |  |  |  |  |  | 221d | 0d |  | 40h |
| 114 | 2.13 | Readiness Review Preparation |  | 4d | 2007-09-27 | 2007-10-02 | 113 |  |  |  |  |  | 221d | 0d |  |  |
| 115 | 2.14 | Readiness Review | milestone | 0d | 2007-10-02 | 2007-10-02 | 114 |  |  |  |  |  | 221d | 0d | start no earlier than 2007-08-15 |  |
| 116 | 2.15 | **Workshop** |  | 57d | 2007-07-23 | 2007-10-09 |  |  |  |  |  |  | 221d |  |  | 112h |
| 117 | 2.15.1 | Set workshop schedule/activities |  | 1d | 2007-07-23 | 2007-07-23 | 109 |  |  | 2006-01-04 | 2006-01-04 | 1d? | 257d | 0d |  | 112h |
| 118 | 2.15.2 | Prepare workshop/demo deployment |  | 15d | 2007-07-24 | 2007-08-13 | 117 |  |  |  |  |  | 257d | 36d |  |  |
| 119 | 2.15.3 | Workshop |  | 5d | 2007-10-03 | 2007-10-09 | 118, 115 |  |  | 2006-12-04 | 2006-12-04 | 1d? | 221d |  |  |  |
| 120 | 2.16 | **Documentation** |  | 35d? | 2007-05-28 | 2007-07-13 |  |  |  |  |  |  | 283d |  |  | 120h |
| 121 | 2.16.1 | Finalized CDs? |  | 5d? | 2007-06-25 | 2007-06-29 | 102 |  |  |  |  |  | 283d | 0d |  | 40h |
| 122 | 2.16.2 | Software user manual |  | 10d | 2007-07-02 | 2007-07-13 | 121 |  |  |  |  |  | 283d |  |  | 80h |
| 123 | 2.16.3 | ME Manual |  | 10d | 2007-05-28 | 2007-06-08 | 101 |  |  |  |  |  | 308d |  |  |  |
| 124 | 2.16.4 | EE Manual |  | 10d | 2007-05-28 | 2007-06-08 | 101 |  |  |  |  |  | 308d |  |  |  |

| ID | WBS | Task | Type | Duration | Start | Finish | Predecessors | Complete | Remaining | Total slack | Free slack | Constraint |
| --- | --- | --- | --- | --- | --- | --- | --- | --- | --- | --- | --- | --- |
| 126 | 3 | **MBARI ESP Apps (Surface)** |  | 303d? | 2006-08-02 A | 2007-09-28 |  | 1% | 299.83d? | 228d |  |  |
| 127 | 3.1 | **Rebuild** |  | 55d | 2006-08-02 A | 2006-10-17 |  | 14% | 47.41d | 476d |  |  |
| 128 | 3.1.1 | Rebuild Heaters |  | 8d | 2006-08-02 A | 2006-08-11 A |  | 100% |  |  |  |  |
| 129 | 3.1.2 | Recalibrate |  | 2d | 2006-08-14 | 2006-08-15 | 128 |  |  | 521d |  |  |
| 130 | 3.1.3 | Demoic Acid protocols |  | 2d | 2006-08-14 | 2006-08-15 | 128 |  |  | 281d | 0d |  |
| 131 | 3.1.4 | Test plan |  | 1d | 2006-08-16 | 2006-08-16 | 130 |  |  | 520d |  |  |
| 132 | 3.1.5 | Demoic Acid laboratory runs |  | 3d | 2006-08-16 | 2006-08-18 | 130 |  |  | 281d | 0d |  |
| 133 | 3.1.6 | Demoic acid collaboration |  | 5d | 2006-08-21 | 2006-08-25 | 132 |  |  | 281d | 0d |  |
| 134 | 3.1.7 | Image Analysis Meeting | milestone | 0d | 2006-08-23 | 2006-08-23 | 132 |  |  | 516d |  | start no earlier than 2006-08-23 |
| 135 | 3.1.8 | Engineering tests |  | 2d | 2006-08-28 | 2006-08-29 | 133 |  |  | 281d | 0d |  |
| 136 | 3.1.9 | C. Preston's runs |  | 3d | 2006-08-30 | 2006-09-01 | 135 |  |  | 281d | 0d |  |
| 137 | 3.1.10 | Lab tests |  | 15d | 2006-09-04 | 2006-09-22 | 136 |  |  | 281d | 0d |  |
| 138 | 3.1.11 | Cold tests |  | 5d | 2006-09-25 | 2006-09-29 | 137 |  |  | 281d | 0d |  |
| 139 | 3.1.12 | Robust test results summary | milestone | 0d | 2006-09-29 | 2006-09-29 | 138 |  |  | 281d | 0d |  |
| 140 | 3.1.13 | Prepare for surface deployment |  | 1d | 2006-10-02 | 2006-10-02 | 139 |  |  | 476d | 0d |  |
| 141 | 3.1.14 | Surface deployment |  | 1d | 2006-10-03 | 2006-10-03 | 140 |  |  | 476d | 0d |  |
| 142 | 3.1.15 | Surface mission |  | 10d | 2006-10-04 | 2006-10-17 | 141 |  |  | 476d | 0d |  |
| 143 | 3.1.16 | Surface recovery | milestone | 0d | 2006-10-17 | 2006-10-17 | 142 |  |  | 476d |  |  |
| 144 | 3.2 | **Replace Bulkhead valves** |  | 72d | 2006-10-02 | 2007-01-09 | 139 |  |  | 281d |  |  |
| 145 | 3.2.1 | Design specifications |  | 7d | 2006-10-02 | 2006-10-10 |  |  |  | 281d | 0d |  |
| 146 | 3.2.2 | ME design |  | 7d | 2006-10-11 | 2006-10-19 | 145 |  |  | 281d | 0d |  |
| 147 | 3.2.3 | EE Design |  | 7d | 2006-10-20 | 2006-10-30 | 146 |  |  | 281d | 0d |  |
| 148 | 3.2.4 | Procurement |  | 21d | 2006-10-31 | 2006-11-28 | 147 |  |  | 281d | 0d |  |
| 149 | 3.2.5 | EE fab. |  | 10d | 2006-11-29 | 2006-12-12 | 148 |  |  | 281d | 0d |  |
| 150 | 3.2.6 | ME Fab. |  | 10d | 2006-12-13 | 2006-12-26 | 149 |  |  | 281d | 0d |  |
| 151 | 3.2.7 | Testing |  | 10d | 2006-12-27 | 2007-01-09 | 150 |  |  | 281d | 0d |  |

| ID | WBS | Task | Type | Duration | Start | Finish | Predecessors | Total slack | Free slack | Constraint |
| --- | --- | --- | --- | --- | --- | --- | --- | --- | --- | --- |
| 152 | 3.3 | **Puck Development (13mm)** |  | 125d | 2007-01-10 | 2007-07-03 | 139 | 281d |  |  |
| 153 | 3.3.1 | Determine specifications |  | 20d | 2007-01-10 | 2007-02-06 | 151 | 281d | 0d |  |
| 154 | 3.3.2 | Drawings |  | 5d | 2007-02-07 | 2007-02-13 | 153 | 281d | 0d |  |
| 155 | 3.3.3 | Procure |  | 90d | 2007-02-14 | 2007-06-19 | 154 | 281d | 0d |  |
| 156 | 3.3.4 | Test |  | 10d | 2007-06-20 | 2007-07-03 | 155 | 281d | 0d |  |
| 157 | 3.3.5 | Pucks accepted | milestone | 0d | 2007-07-03 | 2007-07-03 | 156 | 281d | 0d |  |
| 158 | 3.4 | **New Control** |  | 194d | 2007-01-02 | 2007-09-28 |  | 228d |  |  |
| 159 | 3.4.1 | Multi-threaded s/w protocols |  | 10d | 2007-07-04 | 2007-07-17 | 157 | 281d |  |  |
| 160 | 3.4.2 | **GUI s/w control & monitoring** |  | 183d | 2007-01-02 | 2007-09-13 |  | 239d |  |  |
| 161 | 3.4.2.1 | Initial design of GUI framework |  | 60d | 2007-01-02 | 2007-03-26 |  | 239d | 0d | start no earlier than 2007-01-02 |
| 162 | 3.4.2.2 | PDR Preparation |  | 5d | 2007-03-27 | 2007-04-02 | 161 | 239d | 0d |  |
| 163 | 3.4.2.3 | PDR | milestone | 0d | 2007-04-02 | 2007-04-02 | 162 | 239d | 0d |  |
| 164 | 3.4.2.4 | control LLNL block |  | 72d | 2007-04-03 | 2007-07-11 | 163 | 239d | 0d | start no earlier than 2007-01-08 |
| 165 | 3.4.2.5 | Prepare for CDR |  | 5d | 2007-07-12 | 2007-07-18 | 164 | 239d | 0d |  |
| 166 | 3.4.2.6 | CDR | milestone | 0d | 2007-07-18 | 2007-07-18 | 165 | 239d | 0d |  |
| 167 | 3.4.2.7 | state monitoring of core |  | 41d | 2007-07-19 | 2007-09-13 | 166 | 239d | 0d |  |
| 168 | 3.4.2.8 | Readiness Review | milestone | 0d | 2007-09-13 | 2007-09-13 | 167 | 239d |  |  |
| 169 | 3.4.3 | **Data system with database** |  | 194d | 2007-01-02 | 2007-09-28 |  | 228d |  |  |
| 170 | 3.4.3.1 | Initial Design |  | 62d | 2007-01-02 | 2007-03-28 |  | 228d | 0d | start no earlier than 2007-01-02 |
| 171 | 3.4.3.2 | Prepare for PDR |  | 5d | 2007-03-29 | 2007-04-04 | 170 | 228d | 0d |  |
| 172 | 3.4.3.3 | PDR | milestone | 0d | 2007-04-04 | 2007-04-04 | 171 | 228d | 0d |  |
| 173 | 3.4.3.4 | Develop first cut |  | 64d | 2007-04-05 | 2007-07-03 | 172 | 228d | 0d |  |
| 174 | 3.4.3.5 | Prepare for CDR |  | 5d | 2007-07-04 | 2007-07-10 | 173 | 228d | 0d |  |
| 175 | 3.4.3.6 | CDR | milestone | 0d | 2007-07-10 | 2007-07-10 | 174 | 228d | 0d |  |
| 176 | 3.4.3.7 | Finish development |  | 58d | 2007-07-11 | 2007-09-28 | 175 | 228d | 0d |  |
| 177 | 3.4.3.8 | Readiness Review | milestone | 0d | 2007-09-28 | 2007-09-28 | 176 | 228d |  |  |

| ID | WBS | Task | Type | Duration | Start | Finish | Predecessors | Total slack | Free slack | Constraint | Work |
| --- | --- | --- | --- | --- | --- | --- | --- | --- | --- | --- | --- |
| 178 | 3.5 | **Deployments** |  | 134d? | 2007-03-26 | 2007-09-27 |  | 0d |  |  |  |
| 179 | 3.5.1 | Assemble mooring |  | 5d | 2007-03-26 | 2007-03-30 |  | 1d | 0d | start no earlier than 2007-03-26 |  |
| 180 | 3.5.2 | Test Free-Wave |  | 2d | 2007-04-02 | 2007-04-03 | 179 | 1d | 0d |  |  |
| 181 | 3.5.3 | Load Pucks/Reagents |  | 3d | 2007-04-04 | 2007-04-06 | 180 | 1d | 0d |  |  |
| 182 | 3.5.4 | Can |  | 1d | 2007-04-09 | 2007-04-09 | 181 | 1d | 0d |  |  |
| 183 | 3.5.5 | Cold Test |  | 2d | 2007-04-10 | 2007-04-11 | 182 | 1d | 0d |  |  |
| 184 | 3.5.6 | MOB |  | 1d | 2007-04-12 | 2007-04-12 | 183 | 1d |  |  |  |
| 185 | 3.5.7 | Surface 1 |  | 16d | 2007-04-16 | 2007-05-07 | 184 | 0d |  | must start on 2007-04-16 |  |
| 186 | 3.5.8 | DeMOB |  | 1d | 2007-05-08 | 2007-05-08 | 185 | 0d |  |  |  |
| 187 | 3.5.9 | De-Can |  | 1d | 2007-05-09 | 2007-05-09 | 186 | 0d |  |  |  |
| 188 | 3.5.10 | Turn around (Clean out/Load Pucks/Reagents) |  | 3d | 2007-05-10 | 2007-05-14 | 187 | 0d |  |  |  |
| 189 | 3.5.11 | Can |  | 1d | 2007-05-15 | 2007-05-15 | 188 | 0d |  |  |  |
| 190 | 3.5.12 | MOB |  | 1d | 2007-05-16 | 2007-05-16 | 189 | 0d |  |  |  |
| 191 | 3.5.13 | Surface 2 |  | 19d | 2007-05-17 | 2007-06-12 | 190 | 0d |  | must start on 2007-05-17 |  |
| 192 | 3.5.14 | DeMOB |  | 1d | 2007-06-13 | 2007-06-13 | 191 | 11d | 0d |  |  |
| 193 | 3.5.15 | De-Can |  | 1d | 2007-06-14 | 2007-06-14 | 192 | 11d | 0d |  |  |
| 194 | 3.5.16 | Assemble moorings |  | 30d | 2007-06-15 | 2007-07-26 | 193 | 11d | 0d | start no earlier than 2007-06-04 |  |
| 195 | 3.5.17 | Test Free-Waves |  | 5d | 2007-07-27 | 2007-08-02 | 194 | 11d | 0d |  |  |
| 196 | 3.5.18 | Load Pucks/Reagents |  | 4d | 2007-08-03 | 2007-08-08 | 195 | 11d | 0d |  |  |
| 197 | 3.5.19 | Can |  | 1d | 2007-08-09 | 2007-08-09 | 196 | 11d | 0d |  |  |
| 198 | 3.5.20 | Cold Test |  | 2d | 2007-08-10 | 2007-08-13 | 197 | 11d | 0d |  |  |
| 199 | 3.5.21 | MOB |  | 1d | 2007-08-14 | 2007-08-14 | 198 | 11d |  |  |  |
| 200 | 3.5.22 | Networked Surface |  | 21d? | 2007-08-30 | 2007-09-27 | 199 | 0d |  | must start on 2007-08-30 |  |
| 202 | 4 | **Moore (Walt Array)** |  | 438d? | 2006-08-02 | 2008-04-07 |  | 93d |  |  | 80h |
| 203 | 4.1 | **Micro-Fluidic Block** |  | 438d? | 2006-08-02 | 2008-04-07 |  | 93d |  |  | 80h |
| 204 | 4.1.1 | **Micro-Fluid Block Concept** |  | 65d | 2006-10-02 | 2006-12-29 |  | 242d |  |  |  |
| 205 | 4.1.1.1 | Ready electronics |  | 20d | 2006-10-02 | 2006-10-27 |  | 242d | 0d | start no earlier than 2006-10-02 |  |
| 206 | 4.1.1.2 | Assemble temporary setup |  | 15d | 2006-10-30 | 2006-11-17 | 205 | 453d |  |  |  |
| 207 | 4.1.1.3 | Assemble temporary setup |  | 10d | 2006-10-30 | 2006-11-10 | 205 | 242d | 0d |  |  |
| 208 | 4.1.1.4 | Develop control s/w |  | 10d | 2006-11-13 | 2006-11-24 | 207 | 242d | 0d |  |  |
| 209 | 4.1.1.5 | Test slug and valve control |  | 15d | 2006-11-27 | 2006-12-15 | 208 | 242d | 0d |  |  |
| 210 | 4.1.1.6 | Concept design document |  | 3d | 2006-12-18 | 2006-12-20 | 209 | 242d | 0d |  |  |
| 211 | 4.1.1.7 | PDR Preparation |  | 7d | 2006-12-21 | 2006-12-29 | 210 | 242d | 0d |  |  |
| 212 | 4.1.1.8 | PDR | milestone | 0d | 2006-12-29 | 2006-12-29 | 211 | 242d | 0d |  |  |

| ID | WBS | Task | Type | Duration | Start | Finish | Predecessors | Total slack | Free slack | Constraint | Work |
| --- | --- | --- | --- | --- | --- | --- | --- | --- | --- | --- | --- |
| 213 | 4.1.2 | **Radial Module MFB Design** |  | 48d? | 2007-01-01 | 2007-03-07 |  | 242d |  |  |  |
| 214 | 4.1.2.1 | Mechanical design |  | 14d | 2007-01-01 | 2007-01-18 | 212 | 242d | 0d |  |  |
| 215 | 4.1.2.2 | Electrical Design |  | 14d | 2007-01-19 | 2007-02-07 | 214 | 242d | 0d |  |  |
| 216 | 4.1.2.3 | Software Design |  | 14d | 2007-02-08 | 2007-02-27 | 215 | 242d | 0d |  |  |
| 217 | 4.1.2.4 | Complete design doc |  | 5d | 2007-02-28 | 2007-03-06 | 216 | 242d | 0d |  |  |
| 218 | 4.1.2.5 | CDR Preparation |  | 1d? | 2007-03-07 | 2007-03-07 | 217 | 242d | 0d |  |  |
| 219 | 4.1.2.6 | CDR | milestone | 0d | 2007-03-07 | 2007-03-07 | 218 | 242d | 0d |  |  |
| 220 | 4.1.3 | **Plug-in Module Benchtop Fabrication** |  | 133d | 2007-03-08 | 2007-09-10 |  | 242d |  |  |  |
| 221 | 4.1.3.1 | Procure fluidic parts |  | 21d | 2007-03-08 | 2007-04-05 | 219 | 242d | 0d |  |  |
| 222 | 4.1.3.2 | fabrication of assembly |  | 21d | 2007-04-06 | 2007-05-04 | 221 | 242d | 0d |  |  |
| 223 | 4.1.3.3 | Electrical assembly |  | 21d | 2007-05-07 | 2007-06-04 | 222 | 242d | 0d |  |  |
| 224 | 4.1.3.4 | S/W development |  | 30d | 2007-06-05 | 2007-07-16 | 223 | 242d | 0d |  |  |
| 225 | 4.1.3.5 | S/W Testing |  | 30d | 2007-07-17 | 2007-08-27 | 224 | 242d | 0d |  |  |
| 226 | 4.1.3.6 | Calibration & Testing |  | 10d | 2007-08-28 | 2007-09-10 | 225 | 242d |  |  |  |
| 227 | 4.1.4 | **MFB Development** |  | 220d | 2007-06-04 | 2008-04-07 |  | 93d |  |  |  |
| 228 | 4.1.4.1 | MFB spec's Benchtop | milestone | 0d | 2007-06-04 | 2007-06-04 |  | 288d | 65d | start no earlier than 2007-06-04 |  |
| 229 | 4.1.4.2 | MFB+SPE | milestone | 0d | 2007-09-03 | 2007-09-03 | 228 | 223d | 5d | start no earlier than 2007-09-03 |  |
| 230 | 4.1.4.3 | PCR from LLNL | milestone | 0d | 2007-09-10 | 2007-09-10 | 229 | 218d | 125d | start no earlier than 2007-09-10 |  |
| 231 | 4.1.4.4 | MFB+SPE+PCR Benchtop | milestone | 0d | 2008-03-03 | 2008-03-03 | 230 | 93d | 0d | start no earlier than 2008-03-03 |  |
| 232 | 4.1.4.5 | Integration |  | 10d | 2008-03-03 | 2008-03-14 | 231 | 93d | 0d |  |  |
| 233 | 4.1.4.6 | Scripting |  | 15d | 2008-03-17 | 2008-04-04 | 232 | 93d | 0d |  |  |
| 234 | 4.1.4.7 | MFB+SPE+PCR+Core Shallow | milestone | 0d | 2008-04-07 | 2008-04-07 | 233 | 93d |  | start no earlier than 2008-04-07 |  |
| 236 | 4.1.5 | **Assay Development** |  | 10d? | 2006-08-02 | 2006-08-15 |  | 521d |  |  | 80h |
| 237 | 4.1.5.1 | SH Assay Development & Testing |  | 1d? | 2006-08-02 | 2006-08-02 |  | 521d | 0d |  | 8h |
| 238 | 4.1.5.2 | PCR Assay Development & Testing |  | 1d? | 2006-08-03 | 2006-08-03 | 237 | 521d | 0d |  | 8h |
| 239 | 4.1.5.3 | Probe validation and calibration |  | 1d? | 2006-08-04 | 2006-08-04 | 238 | 521d | 0d |  | 8h |
| 240 | 4.1.5.4 | Identify possible positive control |  | 1d? | 2006-08-07 | 2006-08-07 | 239 | 521d | 0d |  | 8h |
| 241 | 4.1.5.5 | Reagent stability test |  | 1d? | 2006-08-08 | 2006-08-08 | 240 | 521d | 0d |  | 8h |
| 242 | 4.1.5.6 | Bench comparison w/ realistic sample volume |  | 1d? | 2006-08-09 | 2006-08-09 | 241 | 521d | 0d |  | 8h |
| 243 | 4.1.5.7 | Run hybrid on bench, test with cold |  | 1d? | 2006-08-10 | 2006-08-10 | 242 | 521d | 0d |  | 8h |

| ID | WBS | Task | Type | Duration | Start | Finish | Predecessors | Total slack | Free slack | Constraint | Work |
| --- | --- | --- | --- | --- | --- | --- | --- | --- | --- | --- | --- |
| 244 | 4.1.5.8 | **Science Test** |  | 3d? | 2006-08-11 | 2006-08-15 |  | 521d |  |  | 24h |
| 245 | 4.1.5.8.1 | ESP lab test (existing unit) |  | 1d? | 2006-08-11 | 2006-08-11 | 243 | 521d | 0d |  | 8h |
| 246 | 4.1.5.8.2 | ESP Lab test (ASTEP dedicated unit) |  | 1d? | 2006-08-14 | 2006-08-14 | 245 | 521d | 0d |  | 8h |
| 247 | 4.1.5.8.3 | Presentation and publications |  | 1d? | 2006-08-15 | 2006-08-15 | 246 | 521d |  |  | 8h |
| 248 | 4.2 | **Walt Specs** |  | 89d | 2006-09-20 | 2007-01-22 |  | 102d |  |  |  |
| 249 | 4.2.1 | visit Tufts | milestone | 0d | 2006-09-20 | 2006-09-20 |  | 102d | 0d | start no earlier than 2006-09-20 |  |
| 250 | 4.2.2 | Develop ICD |  | 40d | 2006-09-20 | 2006-11-14 | 249 | 102d | 0d |  |  |
| 251 | 4.2.3 | Initial design |  | 40d | 2006-11-15 | 2007-01-09 | 250 | 102d | 0d |  |  |
| 252 | 4.2.4 | PDR Preparation |  | 9d | 2007-01-10 | 2007-01-22 | 251 | 102d | 0d |  |  |
| 253 | 4.2.5 | PDR | milestone | 0d | 2007-01-22 | 2007-01-22 | 252 | 102d | 0d |  |  |
| 254 | 4.3 | **Walt benchtop design** |  | 104d | 2007-01-10 | 2007-06-04 | 251 | 111d |  |  |  |
| 255 | 4.3.1 | Optical design |  | 60d | 2007-01-23 | 2007-04-16 | 253 | 102d | 0d |  |  |
| 256 | 4.3.2 | Electrical design |  | 60d | 2007-01-10 | 2007-04-03 | 251 | 356d |  |  |  |
| 257 | 4.3.3 | Software design |  | 60d | 2007-01-10 | 2007-04-03 | 251 | 356d |  |  |  |
| 258 | 4.3.4 | Mechanical design |  | 30d | 2007-04-17 | 2007-05-28 | 255 | 102d | 0d |  |  |
| 259 | 4.3.5 | CDR Preparation |  | 5d | 2007-05-29 | 2007-06-04 | 258 | 102d | 0d |  |  |
| 260 | 4.3.6 | CDR | milestone | 0d | 2007-06-04 | 2007-06-04 | 259 | 102d | 0d |  |  |
| 261 | 4.4 | **Walt benchtop dev.** |  | 210d | 2007-06-05 | 2008-03-24 |  | 102d |  |  |  |
| 262 | 4.4.1 | Optical procurement |  | 60d | 2007-06-05 | 2007-08-27 | 260 | 102d | 0d |  |  |
| 263 | 4.4.2 | Electrical procurement |  | 30d | 2007-06-05 | 2007-07-16 | 260 | 252d | 0d |  |  |
| 264 | 4.4.3 | Mechanical procurement |  | 30d | 2007-06-05 | 2007-07-16 | 260 | 252d | 0d |  |  |
| 265 | 4.4.4 | Optical assembly & testing |  | 60d | 2007-08-28 | 2007-11-19 | 262 | 102d | 0d |  |  |
| 266 | 4.4.5 | Electrical fab. |  | 30d | 2007-07-17 | 2007-08-27 | 263 | 252d |  |  |  |
| 267 | 4.4.6 | Mechanical fab. |  | 30d | 2007-07-17 | 2007-08-27 | 264 | 252d |  |  |  |
| 268 | 4.4.7 | Software development |  | 60d | 2007-11-20 | 2008-02-11 | 265 | 102d | 0d |  |  |
| 269 | 4.4.8 | Testing |  | 30d | 2008-02-12 | 2008-03-24 | 268 | 102d |  |  |  |

| ID | WBS | Task | Type | Duration | Start | Finish | Predecessors | Total slack | Free slack | Constraint | Resources | Work |
| --- | --- | --- | --- | --- | --- | --- | --- | --- | --- | --- | --- | --- |
| 270 | 5 | **C-MORE** |  | 243d | 2007-01-08 | 2007-12-12 |  | 175d |  |  |  |  |
| 271 | 5.1 | **cmore scoping** |  | 33d | 2007-01-08 | 2007-02-21 |  | 175d | 0d |  |  |  |
| 272 | 5.1.1 | Hawaii trip |  | 3d | 2007-01-08 | 2007-01-10 |  | 175d | 0d | start no earlier than 2007-01-08 |  |  |
| 273 | 5.1.2 | Initial specifications |  | 30d | 2007-01-11 | 2007-02-21 | 272 | 175d |  |  |  |  |
| 274 | 5.2 | TBD Development and Deployment |  | 210d | 2007-02-22 | 2007-12-12 | 271 | 175d |  |  |  |  |
| 276 | 6 | **2008 Planning** |  | 78d? | 2007-06-11 | 2007-09-27 |  | 230d |  |  |  | 160h |
| 277 | 6.1 | Develop 2008 Plan/Abstract |  | 20d | 2007-06-11 | 2007-07-06 |  | 288d |  | start no earlier than 2007-06-11 | Doug | 160h |
| 278 | 6.2 | Abstract Due 8:00 AM | milestone | 0d | 2007-07-10 | 2007-07-10 |  | 287d |  | start no earlier than 2007-07-10 |  |  |
| 279 | 6.3 | Team Presentations | milestone | 0d | 2007-07-17 | 2007-07-17 |  | 282d |  | start no earlier than 2007-07-17 |  |  |
| 280 | 6.4 | MT Feedback | milestone | 0d | 2007-07-20 | 2007-07-20 |  | 264d | 0d | start no earlier than 2007-07-20 |  |  |
| 281 | 6.5 | Develop Proposal |  | 15d | 2007-07-20 | 2007-08-09 | 280 | 264d |  |  |  |  |
| 282 | 6.6 | Phase 1 DUE 8:00 AM | milestone | 0d | 2007-08-14 | 2007-08-14 |  | 262d |  | start no earlier than 2007-08-14 |  |  |
| 283 | 6.7 | MT Feedback | milestone | 0d | 2007-09-19 | 2007-09-19 |  | 231d | 0d | start no earlier than 2007-09-19 |  |  |
| 284 | 6.8 | Revise Proposal |  | 5d? | 2007-09-19 | 2007-09-25 | 283 | 231d | 1d |  |  |  |
| 285 | 6.9 | Phase 2 DUE 8:00 AM | milestone | 0d | 2007-09-27 | 2007-09-27 | 284 | 230d |  | start no earlier than 2007-09-27 |  |  |
